# MS_Project_SAE

Schedule from MS Project, 2024-09-09 to 2025-03-19, status date 2024-11-26, 1.5 hours a day, costs in €, A marks actual dates.

## Calendars

- SAE: Mon-Thu 09:00-10:30; Fri 09:00-12:00, 14:00-18:00; Sat-Sun off. Exceptions (off unless hours are given): 2024-09-09 to 2025-04-06 (Chômage, recurring), 2024-10-28 to 2024-11-03 (Vacances toussaints), 2024-11-11 (Armistice), 2024-12-21 to 2025-01-05 (Vacances Noël), 2025-02-24 to 2025-03-02 (Vacances Février).

## Resources

| Resource | Rate |
| --- | --- |
| Kévin | 40 |
| Kentin | 40 |
| Maxime | 40 |
| Léni | 40 |
| Tommy | 40 |
| Louis | 40 |

## Schedule

| ID | WBS | Task | Duration | Start | Finish | Predecessors | Complete | Remaining | Baseline start | Baseline finish | Baseline duration | Total slack | Free slack | Constraint | Deadline | Resources | Work | Actual work | Cost | Baseline cost | Actual cost |
| --- | --- | --- | --- | --- | --- | --- | --- | --- | --- | --- | --- | --- | --- | --- | --- | --- | --- | --- | --- | --- | --- |
| 1 | 1 | **WikiFantasy** | 93.53d | 2024-09-09 A | 2025-03-19 |  | 53% | 44.29d | 2024-09-09 | 2025-03-19 | 93.53d | 9.47d |  | finish no later than 2025-04-04 |  |  | 524h | 224.58h | 20,959.92 | 20,960 | 8,983.26 |
| 2 | 1.1 | **Analyse** | 7.83d | 2024-09-09 A | 2024-09-19 A |  | 100% |  | 2024-09-09 | 2024-09-19 | 7.83d |  |  |  | 2024-09-22 |  | 38h | 38h | 1,520 | 1,520 | 1,520 |
| 3 | 1.1.1 | Contexte | 1.5h | 2024-09-09 A | 2024-09-09 A |  | 100% |  | 2024-09-09 | 2024-09-09 | 1.5h |  |  |  |  | Louis; Tommy | 3h | 3h | 120 | 120 | 120 |
| 4 | 1.1.2 | Personas | 1.42h | 2024-09-11 A | 2024-09-11 A | 3 | 100% |  | 2024-09-11 | 2024-09-11 | 1.42h |  |  |  |  | Louis; Tommy | 2h | 2h | 80 | 80 | 80 |
| 5 | 1.1.3 | User stories | 2h | 2024-09-11 A | 2024-09-16 A | 4, 3 | 100% |  | 2024-09-11 | 2024-09-16 | 2h |  |  |  |  | Louis; Tommy | 2h | 2h | 80 | 80 | 80 |
| 6 | 1.1.4 | Use case | 3h | 2024-09-11 A | 2024-09-17 A | 3 | 100% |  | 2024-09-11 | 2024-09-17 | 3h |  |  |  |  | Louis; Tommy | 3h | 3h | 120 | 120 | 120 |
| 7 | 1.1.5 | Sketch | 2.25h | 2024-09-10 A | 2024-09-11 A | 3 | 100% |  | 2024-09-10 | 2024-09-11 | 2.25h |  |  |  |  | Kentin; Louis; Tommy | 6h | 6h | 240 | 240 | 240 |
| 8 | 1.1.6 | Maquette | 3h | 2024-09-11 A | 2024-09-16 A | 7, 3 | 100% |  | 2024-09-11 | 2024-09-16 | 3h |  |  |  |  | Kentin; Kévin; Léni; Maxime | 12h | 12h | 480 | 480 | 480 |
| 9 | 1.1.7 | Storyboard | 5h | 2024-09-16 A | 2024-09-19 A | 8, 3 | 100% |  | 2024-09-16 | 2024-09-19 | 5h |  |  |  |  | Kentin; Kévin | 5h | 5h | 200 | 200 | 200 |
| 10 | 1.1.8 | Diagramme de flux | 3.33h | 2024-09-11 A | 2024-09-18 A | 7, 3 | 100% |  | 2024-09-11 | 2024-09-18 | 3.33h |  |  |  |  | Kentin; Kévin; Léni; Maxime | 5h | 5h | 200 | 200 | 200 |
| 11 | 1.2 | **Base de données** | 26.39d | 2024-09-19 A | 2024-11-14 A | 2 | 100% |  | 2024-09-19 | 2024-11-14 | 26.39d |  |  | finish no later than 2024-11-17 | 2024-11-17 |  | 12h | 12h | 479.96 | 480 | 479.96 |
| 12 | 1.2.1 | MCD | 2h | 2024-09-19 A | 2024-09-24 A |  | 100% |  | 2024-09-19 | 2024-09-24 | 2h |  |  |  |  | Louis; Tommy | 4h | 4h | 160 | 160 | 160 |
| 13 | 1.2.2 | MLD | 1h | 2024-10-07 A | 2024-10-07 A |  | 100% |  | 2024-10-07 | 2024-10-07 | 1h |  |  |  |  | Louis; Tommy | 2h | 2h | 80 | 80 | 80 |
| 14 | 1.2.3 | Initialisation BDD | 1h | 2024-10-07 A | 2024-10-21 A | 12, 13 | 100% |  | 2024-10-07 | 2024-10-21 | 1h |  |  |  |  | Louis; Maxime; Tommy; Léni | 2h | 2h | 80 | 80 | 80 |
| 15 | 1.2.4 | Création du jeu de données | 1.89h | 2024-10-23 A | 2024-11-06 A | 14 | 100% |  | 2024-10-23 | 2024-11-06 | 1.89h |  |  |  |  | Kévin; Léni; Louis; Tommy | 3h | 3h | 119.96 | 120 | 119.96 |
| 16 | 1.2.5 | Deployer BDD | 0.61h | 2024-11-13 A | 2024-11-14 A | 15 | 100% |  | 2024-11-13 | 2024-11-14 | 0.61h |  |  |  |  | Maxime; Kentin | 1h | 1h | 40 | 40 | 40 |
| 17 | 1.3 | **Application WEB** | 25.34d | 2024-09-19 A | 2024-11-13 | 2 | 99% | 0.27d | 2024-09-19 | 2024-11-13 | 25.34d | 5.18d | 0d | finish no later than 2024-11-21 | 2024-11-21 |  | 176h | 174.58h | 7,039.97 | 7,040 | 6,983.3 |
| 18 | 1.3.1 | **PHP** | 16.67d | 2024-09-19 A | 2024-10-21 A | 2 | 100% |  | 2024-09-19 | 2024-10-21 | 16.67d |  |  |  | 2024-11-21 |  | 96h | 96h | 3,839.97 | 3,840 | 3,839.97 |
| 19 | 1.3.1.1 | Gateway | 11.18h | 2024-09-30 A | 2024-10-21 A | 9 | 100% |  | 2024-09-30 | 2024-10-21 | 11.18h |  |  |  |  | Kentin; Kévin; Léni; Louis; Maxime; Tommy | 24h | 24h | 960 | 960 | 960 |
| 20 | 1.3.1.2 | Model | 19.4h | 2024-09-24 A | 2024-10-16 A |  | 100% |  | 2024-09-24 | 2024-10-15 | 18.15h |  |  |  |  | Kentin; Kévin; Léni; Louis; Tommy; Maxime | 32h | 32h | 1,280 | 1,280 | 1,280 |
| 21 | 1.3.1.3 | Controller | 17.28h | 2024-09-19 A | 2024-10-10 A |  | 100% |  | 2024-09-19 | 2024-10-10 | 17.28h |  |  |  |  | Kentin; Kévin; Léni; Louis; Maxime; Tommy | 40h | 40h | 1,599.97 | 1,600 | 1,599.97 |
| 22 | 1.3.2 | **Vues** | 25.34d | 2024-09-19 A | 2024-11-13 A |  | 100% |  | 2024-09-19 | 2024-11-13 | 25.34d |  |  |  | 2024-11-21 |  | 56h | 56h | 2,240 | 2,240 | 2,240 |
| 23 | 1.3.2.1 | Bandeau | 3h | 2024-09-19 A | 2024-09-24 A |  | 100% |  | 2024-09-19 | 2024-09-24 | 3h |  |  |  |  | Kentin; Maxime | 6h | 6h | 240 | 240 | 240 |
| 24 | 1.3.2.2 | Accueil | 3.86h | 2024-11-05 A | 2024-11-12 A | 23 | 100% |  | 2024-11-05 | 2024-11-12 | 3.86h |  |  |  |  | Kentin; Maxime | 6h | 6h | 240 | 240 | 240 |
| 25 | 1.3.2.3 | Profil | 12h | 2024-10-09 A | 2024-10-23 A | 23 | 100% |  | 2024-10-09 | 2024-10-23 | 12h |  |  |  |  | Léni | 12h | 12h | 480 | 480 | 480 |
| 26 | 1.3.2.4 | Login/Signup | 7.5h | 2024-10-08 A | 2024-10-22 A | 23 | 100% |  | 2024-10-08 | 2024-10-22 | 7.5h |  |  |  |  | Kévin; Léni; Louis; Tommy | 10h | 10h | 400 | 400 | 400 |
| 27 | 1.3.2.5 | Citation | 4h | 2024-11-05 A | 2024-11-12 A | 23 | 100% |  | 2024-11-05 | 2024-11-12 | 4h |  |  |  |  | Kévin | 4h | 4h | 160 | 160 | 160 |
| 28 | 1.3.2.6 | Recherche | 4.46h | 2024-10-24 A | 2024-11-05 A | 23 | 100% |  | 2024-10-24 | 2024-11-05 | 4.46h |  |  |  |  | Kentin; Maxime | 6h | 6h | 240 | 240 | 240 |
| 29 | 1.3.2.7 | Quiz | 5h | 2024-10-08 A | 2024-10-14 A | 23 | 100% |  | 2024-10-08 | 2024-10-14 | 5h |  |  |  |  | Louis; Tommy | 10h | 10h | 400 | 400 | 400 |
| 30 | 1.3.2.8 | Favoris | 2h | 2024-11-07 A | 2024-11-13 A | 23 | 100% |  | 2024-11-07 | 2024-11-13 | 2h |  |  |  |  | Maxime | 2h | 2h | 80 | 80 | 80 |

| ID | WBS | Task | Duration | Start | Finish | Predecessors | Complete | Remaining | Baseline start | Baseline finish | Baseline duration | Total slack | Free slack | Constraint | Deadline | Resources | Work | Actual work | Cost | Baseline cost | Actual cost |
| --- | --- | --- | --- | --- | --- | --- | --- | --- | --- | --- | --- | --- | --- | --- | --- | --- | --- | --- | --- | --- | --- |
| 31 | 1.3.3 | **Test et deploiement** | 5.91d | 2024-10-21 A | 2024-11-06 | 18 | 88% | 0.72d | 2024-10-21 | 2024-11-06 | 5.91d | 7.94d |  | finish no later than 2024-11-21 | 2024-11-21 |  | 24h | 22.58h | 960 | 960 | 903.33 |
| 32 | 1.3.3.1 | Tests | 6.91h | 2024-10-21 A | 2024-11-05 A |  | 100% |  | 2024-10-21 | 2024-11-05 | 6.91h |  |  |  |  | Kentin; Kévin; Léni; Louis; Maxime; Tommy | 20h | 20h | 800 | 800 | 800 |
| 33 | 1.3.3.2 | Deploiement | 1.77h | 2024-11-05 A | 2024-11-06 | 32 | 40% | 1.06h | 2024-11-05 | 2024-11-06 | 1.77h | 7.94d |  |  |  | Kentin; Kévin; Léni; Louis; Maxime; Tommy | 4h | 2.58h | 160 | 160 | 103.33 |
| 34 | 1.4 | **Application web administrateur** | 22.72d | 2024-11-13 | 2025-01-06 | 17, 2 |  |  | 2024-11-13 | 2025-01-06 | 22.72d | 5.18d | 0d | finish no later than 2025-01-19 | 2025-01-19 |  | 93h |  | 3,720 | 3,720 |  |
| 35 | 1.4.1 | **Web admin** | 22.72d | 2024-11-13 | 2025-01-06 |  |  |  | 2024-11-13 | 2025-01-06 | 22.72d | 5.18d |  |  |  |  | 93h |  | 3,720 | 3,720 |  |
| 36 | 1.4.1.1 | Diagramme UML | 6.96h | 2024-11-13 | 2024-11-20 |  |  |  | 2024-11-13 | 2024-11-20 | 6.96h | 5.18d | 0d |  |  | Kentin; Kévin; Léni; Louis; Maxime; Tommy | 15h |  | 600 | 600 |  |
| 37 | 1.4.1.2 | Faire le frontend | 13.14h | 2024-11-20 | 2024-12-05 | 36 |  |  | 2024-11-20 | 2024-12-05 | 13.14h | 9.15d | 2.05d |  |  | Kentin; Kévin; Léni; Louis; Maxime; Tommy | 28h |  | 1,120 | 1,120 |  |
| 38 | 1.4.1.3 | Faire le backend | 13.24h | 2024-11-25 | 2024-12-10 | 36 |  |  | 2024-11-25 | 2024-12-10 | 13.24h | 7.1d | 0d |  |  | Kentin; Kévin; Léni; Louis; Maxime; Tommy | 28h |  | 1,120 | 1,120 |  |
| 39 | 1.4.1.4 | Tester le code | 10.9h | 2024-12-10 | 2025-01-06 | 36, 37, 38 |  |  | 2024-12-10 | 2025-01-06 | 10.9h | 7.1d |  |  |  | Kentin; Kévin; Léni; Louis; Maxime; Tommy | 22h |  | 880 | 880 |  |
| 40 | 1.5 | **Application mobile** | 28.41d | 2025-01-06 | 2025-03-04 | 2, 34 |  |  | 2025-01-06 | 2025-03-04 | 28.41d | 8.03d | 0d | finish no later than 2025-04-04 | 2025-04-04 |  | 122h |  | 4,880 | 4,880 |  |
| 41 | 1.5.1 | Faire le diagramme UML | 4h | 2025-01-06 | 2025-01-09 |  |  |  | 2025-01-06 | 2025-01-09 | 4h | 8.03d | 0d |  |  | Kentin; Kévin; Léni; Louis; Maxime; Tommy | 24h |  | 960 | 960 |  |
| 42 | 1.5.2 | Faire des vues | 13.56h | 2025-01-15 | 2025-02-11 | 41 |  |  | 2025-01-15 | 2025-02-11 | 13.56h | 8.03d | 0d |  |  | Kentin; Kévin; Léni; Louis; Maxime; Tommy | 24h |  | 960 | 960 |  |
| 43 | 1.5.3 | Faire le backend | 24.75h | 2025-01-09 | 2025-02-10 | 41 |  |  | 2025-01-09 | 2025-02-10 | 24.75h | 9.76d | 1.74d |  |  | Kentin; Kévin; Léni; Louis; Maxime; Tommy | 50h |  | 2,000 | 2,000 |  |
| 44 | 1.5.4 | Tester le code | 10.9h | 2025-02-11 | 2025-03-04 | 42, 43 |  |  | 2025-02-11 | 2025-03-04 | 10.9h | 8.03d | 0d |  |  | Kentin; Kévin; Léni; Louis; Maxime; Tommy | 22h |  | 880 | 880 |  |
| 45 | 1.5.5 | Déployer l'application | 0.36h | 2025-03-04 | 2025-03-04 | 44 |  |  | 2025-03-04 | 2025-03-04 | 0.36h | 8.03d |  |  |  | Kentin; Kévin; Léni; Louis; Maxime; Tommy | 2h |  | 80 | 80 |  |
| 46 | 1.6 | **API** | 9.22d | 2025-03-04 | 2025-03-19 | 11, 2, 17, 34, 40 |  |  | 2025-03-04 | 2025-03-19 | 9.22d | 8.03d |  | finish no later than 2025-04-04 | 2025-04-04 |  | 83h |  | 3,320 | 3,320 |  |
| 47 | 1.6.1 | Faire le diagramme UML | 4h | 2025-03-04 | 2025-03-06 |  |  |  | 2025-03-04 | 2025-03-06 | 4h | 8.03d | 0d |  |  | Kentin; Kévin; Léni; Louis; Maxime; Tommy | 24h |  | 960 | 960 |  |
| 48 | 1.6.2 | Faire des routes | 2h | 2025-03-12 | 2025-03-13 | 47 |  |  | 2025-03-12 | 2025-03-13 | 2h | 9.47d | 0d |  |  | Kentin; Kévin; Léni; Louis; Maxime; Tommy | 12h |  | 480 | 480 |  |
| 49 | 1.6.3 | Faire des requêtes à la BDD | 3.33h | 2025-03-06 | 2025-03-12 | 47 |  |  | 2025-03-06 | 2025-03-12 | 3.33h | 10.8d | 1.33d |  |  | Kentin; Kévin; Léni; Louis; Maxime; Tommy | 20h |  | 800 | 800 |  |
| 50 | 1.6.4 | Mettre en place un ORM | 2.5h | 2025-03-13 | 2025-03-18 | 47, 48, 49 |  |  | 2025-03-13 | 2025-03-18 | 2.5h | 9.47d | 0d |  |  | Kentin; Kévin; Léni; Louis; Maxime; Tommy | 15h |  | 600 | 600 |  |
| 51 | 1.6.5 | Tester le code | 2h | 2025-03-18 | 2025-03-19 | 50 |  |  | 2025-03-18 | 2025-03-19 | 2h | 9.47d |  |  |  | Kentin; Kévin; Léni; Louis; Maxime; Tommy | 12h |  | 480 | 480 |  |
